# Maynard Company Furniture Project

Schedule from MS Project, 2013-10-09 to 2013-11-26, costs in $.
New System
MGMT404 - Your Professor's Name

## Calendars

- Standard: Mon-Fri 08:00-12:00, 13:00-17:00; Sat-Sun off. Exceptions (off unless hours are given): 2013-10-05 to 2013-12-28 08:00-12:00 (All Saturdays, recurring), 2013-10-14 (Day Off).

## Resources

| Resource | Group | Rate | Cost per use |
| --- | --- | --- | --- |
| Project Manager | Management | 125 |  |
| Systems Manager | Management | 36.06 |  |
| Systems Administrator | IT Staff | 25 |  |
| Wiring Contractor | Contractor |  |  |
| Financial Officer | Administration | 85 |  |
| Conference Room | Equipment |  | 100 |
| Systems Analyst | IT Staff | 40 |  |

## Schedule

| ID | WBS | Task | Type | Duration | Start | Finish | Predecessors | Total slack | Constraint | Resources | Work | Cost |
| --- | --- | --- | --- | --- | --- | --- | --- | --- | --- | --- | --- | --- |
| 1 | 1 | **Your Professor's New System** |  | 37.5d | 2013-10-09 08:00 | 2013-11-26 17:00 |  | 0d |  |  | 566h | 36,199.69 |
| 2 | 1.1 | **Proposal creation** |  | 14.25d | 2013-10-09 08:00 | 2013-10-28 15:00 |  | 0d |  |  | 256h | 11,339.23 |
| 3 | 1.1.1 | Inventory New Equipment |  | 2d | 2013-10-09 08:00 | 2013-10-10 17:00 |  | 0d |  | Systems Administrator [200%]; Systems Analyst | 48h | 1,440 |
| 4 | 1.1.2 | Assess current department needs |  | 3d | 2013-10-10 17:00 | 2013-10-15 12:00 | 3 | 0d |  | Systems Administrator; Systems Analyst; Systems Manager | 48h | 1,616.92 |
| 5 | 1.1.3 | Design and diagram new system |  | 6.88d | 2013-10-15 13:00 | 2013-10-21 17:00 | 4 | 0d |  | Systems Manager; Systems Analyst | 80h | 3,042.31 |
| 6 | 1.1.4 | Proposal to accounting |  | 3d | 2013-10-21 17:00 | 2013-10-23 15:00 | 5 | 0d |  | Project Manager | 24h | 3,000 |
| 7 | 1.1.5 | Research products and services |  | 3.5d | 2013-10-23 15:00 | 2013-10-28 15:00 | 6 | 0d |  | Systems Analyst [200%] | 56h | 2,240 |
| 8 | 1.2 | **Vendor Selection** |  | 15.75d | 2013-10-28 15:00 | 2013-11-16 12:00 |  | 0d |  |  | 152h | 15,960 |
| 9 | 1.2.1 | Issue RFPs |  | 11.25d | 2013-10-28 15:00 | 2013-11-11 17:00 | 7 | 0d |  | Project Manager; Financial Officer | 112h | 11,760 |
| 10 | 1.2.2 | Evaluate bids |  | 3.75d | 2013-11-11 17:00 | 2013-11-14 12:00 | 9 | 0d |  | Project Manager; Financial Officer | 40h | 4,200 |
| 11 | 1.2.3 | Award contract | milestone | 0d | 2013-11-16 12:00 | 2013-11-16 12:00 | 10FS+2d | 0d |  |  |  |  |
| 12 | 1.3 | **Implement system** |  | 7.5d | 2013-11-18 08:00 | 2013-11-26 17:00 |  | 0d |  |  | 144h | 8,200.46 |
| 13 | 1.3.1 | Purchase equipment |  | 4d | 2013-11-18 08:00 | 2013-11-21 17:00 | 11 | 0d |  | Financial Officer [50%] | 16h | 1,360 |
| 14 | 1.3.2 | Install wiring |  | 3d | 2013-11-21 08:00 | 2013-11-22 16:00 | 13FS-1d | 1.62d |  | Wiring Contractor | 24h | 4,000 |
| 15 | 1.3.3 | Install hardware |  | 3.5d | 2013-11-22 08:00 | 2013-11-25 22:00 | 14FF, 13 | 0d |  | Systems Administrator [200%] | 32h | 800 |
| 16 | 1.3.4 | Install software |  | 3.5d | 2013-11-22 08:00 | 2013-11-25 22:00 | 15FF, 13 | 0d | start no earlier than 2013-11-22 08:00 | Systems Administrator [300%] | 48h | 1,200 |
| 17 | 1.3.5 | Test system |  | 1.25d | 2013-11-26 06:00 | 2013-11-26 17:00 | 16, 15, 14 | 0d |  | Systems Manager; Systems Analyst; Systems Administrator | 24h | 840.46 |
| 18 | 1.4 | **Project Meeting** |  | 32.25d | 2013-10-11 08:00 | 2013-11-22 10:00 |  | 3.25d |  |  | 14h | 700 |
| 19 | 1.4.1 | Project Meeting 1 |  | 2h | 2013-10-11 08:00 | 2013-10-11 10:00 |  | 35.25d | start no earlier than 2013-10-11 08:00 | Conference Room | 2h | 100 |
| 20 | 1.4.2 | Project Meeting 2 |  | 2h | 2013-10-18 08:00 | 2013-10-18 10:00 |  | 30.75d | start no earlier than 2013-10-18 08:00 | Conference Room | 2h | 100 |
| 21 | 1.4.3 | Project Meeting 3 |  | 2h | 2013-10-25 08:00 | 2013-10-25 10:00 |  | 25.25d | start no earlier than 2013-10-25 08:00 | Conference Room | 2h | 100 |
| 22 | 1.4.4 | Project Meeting 4 |  | 2h | 2013-11-01 08:00 | 2013-11-01 10:00 |  | 19.75d | start no earlier than 2013-11-01 08:00 | Conference Room | 2h | 100 |
| 23 | 1.4.5 | Project Meeting 5 |  | 2h | 2013-11-08 08:00 | 2013-11-08 10:00 |  | 14.25d | start no earlier than 2013-11-08 08:00 | Conference Room | 2h | 100 |
| 24 | 1.4.6 | Project Meeting 6 |  | 2h | 2013-11-15 08:00 | 2013-11-15 10:00 |  | 8.75d | start no earlier than 2013-11-15 08:00 | Conference Room | 2h | 100 |
| 25 | 1.4.7 | Project Meeting 7 |  | 2h | 2013-11-22 08:00 | 2013-11-22 10:00 |  | 3.25d | start no earlier than 2013-11-22 08:00 | Conference Room | 2h | 100 |
